# Zmiana lokalizacji

Schedule from MS Project, 2008-04-01 to 2008-05-26.
Przeprowadzka firmy do nowej siedziby
ABC sp z o.o.

## Calendars

- Standardowy: Mon-Fri 09:00-13:00, 14:00-18:00; Sat-Sun off. Exceptions (off unless hours are given): 2008-05-01 (Święto Pracy), 2008-05-22 (Boże Ciało).

## Schedule

| ID | WBS | Task | Type | Duration | Start | Finish | Predecessors | Total slack |
| --- | --- | --- | --- | --- | --- | --- | --- | --- |
| 1 | 1 | Start | milestone | 0d | 2008-04-01 09:00 | 2008-04-01 09:00 |  | 0d |
| 2 | 2 | **Poszukiwanie lokalu** |  | 8.5d? | 2008-04-01 09:00 | 2008-04-11 13:00 |  | 0d |
| 3 | 2.1 | Określenie potrzeb |  | 1d | 2008-04-01 09:00 | 2008-04-01 18:00 | 1 | 0d |
| 4 | 2.2 | Przygotowanie ogłoszenia |  | 0.5d? | 2008-04-02 09:00 | 2008-04-02 13:00 | 3 | 0d |
| 5 | 2.3 | Emisja ogłoszenia | milestone | 0d | 2008-04-02 13:00 | 2008-04-02 13:00 | 4 | 18.5d |
| 6 | 2.4 | **Rozpatrywanie ofert** |  | 5.5d? | 2008-04-02 14:00 | 2008-04-09 18:00 |  | 0d |
| 7 | 2.4.1 | **Ocena ofert** |  | 5.5d? | 2008-04-02 14:00 | 2008-04-09 18:00 |  | 0d |
| 8 | 2.4.1.1 | Definiowanie kryteriów oceny |  | 0.5d | 2008-04-02 14:00 | 2008-04-02 18:00 | 4 | 0d |
| 9 | 2.4.1.2 | Wpisywanie zgłoszonych ofert |  | 1d? | 2008-04-03 09:00 | 2008-04-03 18:00 | 5, 8 | 0d |
| 10 | 2.4.1.3 | Wizyty w lokalach |  | 3d? | 2008-04-04 09:00 | 2008-04-08 18:00 | 9 | 0d |
| 11 | 2.4.1.4 | Przypisywanie ocen |  | 1d | 2008-04-09 09:00 | 2008-04-09 18:00 | 10 | 0d |
| 12 | 2.5 | Spisanie i zebranie ocen |  | 1d | 2008-04-10 09:00 | 2008-04-10 18:00 | 11 | 0d |
| 13 | 2.6 | Wybór lokalu | milestone | 0d | 2008-04-10 18:00 | 2008-04-10 18:00 | 12 | 0d |
| 14 | 2.7 | Wysyłanie powiadomień o decyzji |  | 0.5d | 2008-04-11 09:00 | 2008-04-11 13:00 | 13 | 0d |
| 15 | 3 | **Przygotowania do przeprowadzki** |  | 26d? | 2008-04-11 14:00 | 2008-05-20 13:00 |  | 0d |
| 16 | 3.1 | Opiniowanie umowy |  | 2d | 2008-04-11 14:00 | 2008-04-15 13:00 | 14 | 0d |
| 17 | 3.2 | Podpisanie umowy |  | 2h | 2008-04-15 14:00 | 2008-04-15 16:00 | 16 | 0d |
| 18 | 3.3 | Wypowiedzenie umowy |  | 1h | 2008-04-15 16:00 | 2008-04-15 17:00 | 17 | 26.69d |
| 19 | 3.4 | Zdanie lokalu |  | 0.5d? | 2008-05-20 09:00 | 2008-05-20 13:00 | 26 | 3.06d |
| 20 | 3.5 | Ustalenie terminu przeprowadzki |  | 0.5d? | 2008-04-15 16:00 | 2008-04-16 11:00 | 17 | 18.5d |
| 21 | 3.6 | Aranżacja wnętrz |  | 1mo | 2008-04-15 16:00 | 2008-05-14 16:00 | 17 | 0d |
| 22 | 4 | **Przeprowadzka** |  | 26.31d | 2008-04-16 11:00 | 2008-05-26 14:30 |  | 0d |
| 23 | 4.1 | Poszukiwanie środka transportu |  | 1d | 2008-04-16 11:00 | 2008-04-17 11:00 | 20 | 18.5d |
| 24 | 4.2 | Odebranie lokalu |  | 1d | 2008-05-14 16:00 | 2008-05-15 16:00 | 21, 23 | 0d |
| 25 | 4.3 | Pakowanie wyposażenia |  | 2d | 2008-05-15 16:00 | 2008-05-19 16:00 | 21, 24 | 0d |
| 26 | 4.4 | Wynoszenie wyposażenia |  | 2h | 2008-05-19 16:00 | 2008-05-19 18:00 | 25 | 0d |
| 27 | 4.5 | Załadunek |  | 1h | 2008-05-20 09:00 | 2008-05-20 10:00 | 26 | 0d |
| 28 | 4.6 | Transport |  | 0.5h | 2008-05-20 10:00 | 2008-05-20 10:30 | 27 | 0d |
| 29 | 4.7 | Wyładunek |  | 1h | 2008-05-20 10:30 | 2008-05-20 11:30 | 28 | 0d |
| 30 | 4.8 | Wnoszenie wyposażenia |  | 2h | 2008-05-20 11:30 | 2008-05-20 14:30 | 29 | 0d |
| 31 | 4.9 | Rozlokowanie sprzętu |  | 2d | 2008-05-20 14:30 | 2008-05-23 14:30 | 30 | 0d |
| 32 | 4.10 | Rozlokowanie wyposażenia |  | 2d | 2008-05-20 14:30 | 2008-05-23 14:30 | 30 | 0d |
| 33 | 4.11 | Sprzątanie |  | 1d | 2008-05-23 14:30 | 2008-05-26 14:30 | 31, 32 | 0d |
| 34 | 5 | Koniec | milestone | 0d | 2008-05-26 14:30 | 2008-05-26 14:30 | 19, 33 | 0d |
