# Zmiana lokalizacji

Schedule from MS Project, 2008-04-01 to 2008-05-30, costs in zł.
Przeprowadzka firmy do nowej siedziby
ABC sp z o.o.

## Calendars

- Standardowy: Mon-Fri 09:00-13:00, 14:00-18:00; Sat-Sun off. Exceptions (off unless hours are given): 2008-05-01 (Święto Pracy), 2008-05-22 (Boże Ciało).

## Resources

| Resource | Group | Unit | Rate | Cost per use |
| --- | --- | --- | --- | --- |
| Prezes | Administracja |  | 150 |  |
| Asystentka prezesa | Administracja |  | 30 |  |
| Grafik | Firma zewnętrzna |  | 60 |  |
| Administrator budynku | Służba pomocnicza |  | 20 |  |
| Sekretarka | Administracja |  | 16 |  |
| Prawnik | Firma zewnętrzna |  |  | 150 |
| Firma architektoniczno budowlana | Firma zewnętrzna |  |  | 8000 |
| Pracownik pomocniczy | Pracownicy fizyczni |  | 14 |  |
| Firma transportowa | Firma zewnętrzna |  |  | 5000 |
| Informatyk | Służba pomocnicza |  | 30 |  |
| Elektryk | Pracownicy fizyczni |  | 16 |  |
| Komputer | Sprzęt biurowy |  | 3 |  |
| Sprzątaczka | Służba pomocnicza |  | 10 |  |
| Samochód | Transport |  | 1.25 |  |
| Paliwo | Inne | litr | 3.34 |  |
| Moduł ogłoszeniowy cz-b | Inne | moduł | 180 |  |
| Pojemnik | Sprzęt biurowy | sztuka | 15 |  |
| Koszty reprezentacyjne | Ogólne |  |  |  |
| Koszty delegacji | Ogólne |  |  |  |
| Koszty korespondencji | Ogólne |  |  |  |

## Schedule

| ID | WBS | Task | Type | Duration | Start | Finish | Predecessors | Total slack | Free slack | Constraint | Deadline | Resources | Work | Cost |
| --- | --- | --- | --- | --- | --- | --- | --- | --- | --- | --- | --- | --- | --- | --- |
| 1 | 1 | Start | milestone | 0d | 2008-04-01 09:00 | 2008-04-01 09:00 |  | 3.5d | 0d |  |  |  |  |  |
| 2 | 2 | **Poszukiwanie lokalu** |  | 13.5d? | 2008-04-01 09:00 | 2008-04-18 13:00 |  | 0d |  |  |  | Koszty reprezentacyjne [0.1%] | 144h | 6,934 |
| 3 | 2.1 | Określenie potrzeb |  | 1d | 2008-04-01 09:00 | 2008-04-01 18:00 | 1 | 3.5d | 0d |  |  | Asystentka prezesa; Administrator budynku; Prezes | 24h | 1,600 |
| 4 | 2.2 | Przygotowanie ogłoszenia |  | 0.5d? | 2008-04-02 09:00 | 2008-04-02 13:00 | 3 | 3.5d | 0d | finish no later than 2008-04-07 18:00 |  | Grafik; Komputer | 8h | 252 |
| 5 | 2.3 | Emisja ogłoszenia |  | 1d | 2008-04-10 09:00 | 2008-04-10 18:00 | 4 | 0d |  | must start on 2008-04-10 09:00 |  | Moduł ogłoszeniowy cz-b [3 moduł] |  | 540 |
| 6 | 2.4 | **Rozpatrywanie ofert** |  | 10.5d? | 2008-04-02 14:00 | 2008-04-16 18:00 |  | 0d |  |  |  | Koszty reprezentacyjne [0%] | 92h | 3,164 |
| 7 | 2.4.1 | **Ocena ofert** |  | 10.5d? | 2008-04-02 14:00 | 2008-04-16 18:00 |  | 0d |  |  |  |  | 92h | 2,964 |
| 8 | 2.4.1.1 | Definiowanie kryteriów oceny |  | 0.5d | 2008-04-02 14:00 | 2008-04-02 18:00 | 4 | 6d |  |  |  | Asystentka prezesa; Administrator budynku; Prezes | 12h | 800 |
| 9 | 2.4.1.2 | Wpisywanie zgłoszonych ofert |  | 1d? | 2008-04-11 09:00 | 2008-04-11 18:00 | 5, 8 | 0d |  |  |  | Komputer; Asystentka prezesa | 16h | 264 |
| 10 | 2.4.1.3 | Wizyty w lokalach |  | 3d? | 2008-04-14 09:00 | 2008-04-16 18:00 | 9 | 0d |  |  |  | Asystentka prezesa; Administrator budynku; Koszty delegacji [0.1%] | 48h | 1,500 |
| 11 | 2.4.1.4 | Przypisywanie ocen |  | 1d | 2008-04-16 09:00 | 2008-04-16 18:00 | 10FF | 0d |  |  |  | Asystentka prezesa; Administrator budynku | 16h | 400 |
| 12 | 2.5 | Spisanie i zebranie ocen |  | 1d | 2008-04-17 09:00 | 2008-04-17 18:00 | 11 | 0d |  |  | 2008-05-05 18:00 | Asystentka prezesa; Komputer | 16h | 264 |
| 13 | 2.6 | Wybór lokalu | milestone | 0d | 2008-04-17 18:00 | 2008-04-17 18:00 | 12 | 0d |  |  |  |  |  |  |
| 14 | 2.7 | Wysyłanie powiadomień o decyzji |  | 0.5d | 2008-04-18 09:00 | 2008-04-18 13:00 | 13 | 0d |  |  |  | Sekretarka; Koszty korespondencji [0.1%] | 4h | 114 |
| 15 | 3 | **Przygotowania do przeprowadzki** |  | 25.33d? | 2008-04-18 14:00 | 2008-05-27 16:40 |  | 0d |  |  |  |  | 259h | 11,080 |
| 16 | 3.1 | Opiniowanie umowy |  | 2d | 2008-04-18 14:00 | 2008-04-22 13:00 | 14 | 0d |  |  |  | Prawnik | 16h | 150 |
| 17 | 3.2 | Podpisanie umowy |  | 2h | 2008-04-22 14:00 | 2008-04-22 16:00 | 16 | 0d |  |  |  | Prezes | 2h | 300 |
| 18 | 3.3 | Wypowiedzenie umowy |  | 1h | 2008-04-22 12:00 | 2008-04-22 14:00 | 17SF | 26.81d |  |  |  | Prezes | 1h | 150 |
| 19 | 3.4 | Zdanie lokalu |  | 0.5d? | 2008-05-27 11:40 | 2008-05-27 16:40 | 26 | 2.81d |  |  |  | Prezes; Administrator budynku | 8h | 680 |
| 20 | 3.5 | Ustalenie terminu przeprowadzki |  | 0.5d? | 2008-04-22 16:00 | 2008-04-23 11:00 | 17 | 18.5d | 0d |  |  | Administrator budynku; Asystentka prezesa | 8h | 200 |
| 21 | 3.6 | Aranżacja wnętrz |  | 1mo | 2008-04-22 16:00 | 2008-05-21 16:00 | 17 | 0d |  |  |  | Firma architektoniczno budowlana; Asystentka prezesa [20%]; Administrator budynku [20%] | 224h | 9,600 |
| 22 | 4 | **Przeprowadzka** |  | 25.4d | 2008-04-23 11:00 | 2008-05-30 15:10 |  | 0d |  |  |  |  | 266.5h | 13,220 |
| 23 | 4.1 | Poszukiwanie środka transportu |  | 1d | 2008-04-23 11:00 | 2008-04-24 11:00 | 20 | 18.5d |  |  |  | Sekretarka | 8h | 128 |
| 24 | 4.2 | Odebranie lokalu |  | 1d | 2008-05-21 16:00 | 2008-05-23 16:00 | 21, 23 | 0d |  |  |  | Prezes; Administrator budynku; Koszty reprezentacyjne [1.9%] | 16h | 2,860 |
| 25 | 4.3 | Pakowanie wyposażenia |  | 1.33d | 2008-05-23 16:00 | 2008-05-27 09:40 | 21, 24 | 0d |  |  |  | Pracownik pomocniczy [300%] | 32h | 448 |
| 26 | 4.4 | Wynoszenie wyposażenia |  | 2h | 2008-05-27 09:40 | 2008-05-27 11:40 | 25 | 0d |  |  |  | Pracownik pomocniczy [300%] | 6h | 84 |
| 27 | 4.5 | Załadunek |  | 1h | 2008-05-27 11:10 | 2008-05-27 12:10 | 26FS-2.5% | 0d |  |  |  | Pracownik pomocniczy [300%] | 3h | 42 |
| 28 | 4.6 | Transport |  | 0.5h | 2008-05-27 12:10 | 2008-05-27 12:40 | 27 | 0d |  |  |  | Firma transportowa | 0.5h | 6,300 |
| 29 | 4.7 | Wyładunek |  | 1h | 2008-05-27 12:40 | 2008-05-27 14:40 | 28 | 0d |  |  |  | Pracownik pomocniczy [300%] | 3h | 42 |
| 30 | 4.8 | Wnoszenie wyposażenia |  | 2h | 2008-05-27 14:10 | 2008-05-27 16:10 | 29FS-5% | 0d |  |  |  | Pracownik pomocniczy [300%] | 6h | 84 |
| 31 | 4.9 | Rozlokowanie sprzętu |  | 2d | 2008-05-27 14:40 | 2008-05-29 14:40 | 30FS-7.5% | 0.06d |  |  |  | Pracownik pomocniczy [300%]; Elektryk; Informatyk | 80h | 1,408 |
| 32 | 4.10 | Rozlokowanie wyposażenia |  | 2d | 2008-05-27 15:10 | 2008-05-29 15:10 | 30FS-5% | 0d |  |  |  | Pracownik pomocniczy [300%]; Elektryk; Informatyk | 80h | 1,408 |
| 33 | 4.11 | Sprzątanie |  | 1d | 2008-05-29 15:10 | 2008-05-30 15:10 | 31, 32 | 0d |  |  |  | Pracownik pomocniczy [300%]; Sprzątaczka | 32h | 416 |
| 34 | 5 | Koniec | milestone | 0d | 2008-05-30 15:10 | 2008-05-30 15:10 | 19, 33 | 0d |  |  |  |  |  |  |

Notes:
- 3: Problematykę tą należy dodatkowo skonsultować z Janem Malinowskim i Krystyną Kowalską. Należy wziąć pod uwagę takie elementy jak: / ·wielkość powierzchni / ·podłączenie do internetu / ·klimatyzację

| ID | WBS | Task | Duration | Start | Finish | Total slack | Constraint |
| --- | --- | --- | --- | --- | --- | --- | --- |
| 35 | 6 | **Przygotowanie raportu** | 38.25d | 2008-04-04 09:00 | 2008-05-30 11:00 | 0.06d |  |
| 36 | 6.1 | Przygotowanie raportu 1 | 2h | 2008-04-04 09:00 | 2008-04-04 11:00 | 38.06d | start no earlier than 2008-04-04 09:00 |
| 37 | 6.2 | Przygotowanie raportu 2 | 2h | 2008-04-11 09:00 | 2008-04-11 11:00 | 33.06d | start no earlier than 2008-04-11 09:00 |
| 38 | 6.3 | Przygotowanie raportu 3 | 2h | 2008-04-18 09:00 | 2008-04-18 11:00 | 28.06d | start no earlier than 2008-04-18 09:00 |
| 39 | 6.4 | Przygotowanie raportu 4 | 2h | 2008-04-25 09:00 | 2008-04-25 11:00 | 23.06d | start no earlier than 2008-04-25 09:00 |
| 40 | 6.5 | Przygotowanie raportu 5 | 2h | 2008-05-02 09:00 | 2008-05-02 11:00 | 19.06d | start no earlier than 2008-05-02 09:00 |
| 41 | 6.6 | Przygotowanie raportu 6 | 2h | 2008-05-09 09:00 | 2008-05-09 11:00 | 14.06d | start no earlier than 2008-05-09 09:00 |
| 42 | 6.7 | Przygotowanie raportu 7 | 2h | 2008-05-16 09:00 | 2008-05-16 11:00 | 9.06d | start no earlier than 2008-05-16 09:00 |
| 43 | 6.8 | Przygotowanie raportu 8 | 2h | 2008-05-23 09:00 | 2008-05-23 11:00 | 5.06d | start no earlier than 2008-05-23 09:00 |
| 44 | 6.9 | Przygotowanie raportu 9 | 2h | 2008-05-30 09:00 | 2008-05-30 11:00 | 0.06d | start no earlier than 2008-05-30 09:00 |
