# Zmiana lokalizacji

Schedule from MS Project, 2008-04-01 to 2008-06-11, status date 2008-04-30, costs in zł, A marks actual dates.
Przeprowadzka firmy do nowej siedziby
ABC sp z o.o.

## Calendars

- Standardowy: Mon-Fri 09:00-13:00, 14:00-18:00; Sat-Sun off. Exceptions (off unless hours are given): 2008-05-01 (Święto Pracy), 2008-05-22 (Boże Ciało).
- Wydłużone godziny pracy: Mon-Fri 07:00-14:00, 15:00-23:00; Sat-Sun off. Exceptions (off unless hours are given): 2008-05-01 (Święto Pracy), 2008-05-22 (Boże Ciało).

## Resources

| Resource | Group | Unit | Rate | Cost per use |
| --- | --- | --- | --- | --- |
| Prezes | Administracja |  | 150 |  |
| Asystentka prezesa | Administracja |  | 30 |  |
| Grafik | Firma zewnętrzna |  | 60 |  |
| Administrator budynku | Służba pomocnicza |  | 20 |  |
| Sekretarka | Administracja |  | 16 |  |
| Prawnik | Firma zewnętrzna |  |  | 150 |
| Firma architektoniczno budowlana | Firma zewnętrzna |  |  | 8000 |
| Pracownik pomocniczy | Pracownicy fizyczni |  | 14 |  |
| Firma transportowa | Firma zewnętrzna |  |  | 5000 |
| Informatyk | Służba pomocnicza |  | 30 |  |
| Elektryk | Pracownicy fizyczni |  | 16 |  |
| Komputer | Sprzęt biurowy |  | 3 |  |
| Sprzątaczka | Służba pomocnicza |  | 10 |  |
| Samochód | Transport |  | 1.25 |  |
| Paliwo | Inne | litr | 3.34 |  |
| Moduł ogłoszeniowy cz-b | Inne | moduł | 180 |  |
| Pojemnik | Sprzęt biurowy | sztuka | 15 |  |
| Koszty reprezentacyjne | Ogólne |  |  |  |
| Koszty delegacji | Ogólne |  |  |  |
| Koszty korespondencji | Ogólne |  |  |  |
| Firma przeprowadzkowa | Firma zewnętrzna |  | 200 |  |

## Schedule

| ID | WBS | Task | Type | Duration | Start | Finish | Predecessors | Complete | Remaining | Baseline start | Baseline finish | Baseline duration | Total slack | Constraint | Deadline | Calendar | Resources | Work | Actual work | Cost | Baseline cost | Actual cost |
| --- | --- | --- | --- | --- | --- | --- | --- | --- | --- | --- | --- | --- | --- | --- | --- | --- | --- | --- | --- | --- | --- | --- |
| 1 | 1 | Start | milestone | 0d | 2008-04-01 09:00 A | 2008-04-01 09:00 A |  | 100% |  | 2008-04-01 09:00 | 2008-04-01 09:00 | 0d |  |  |  |  |  |  |  |  |  |  |
| 2 | 2 | **Poszukiwanie lokalu** |  | 13.62d? | 2008-04-01 09:00 A | 2008-04-18 15:00 A |  | 100% |  | 2008-04-01 09:00 | 2008-04-18 15:00 | 13.62d? |  |  |  |  | Koszty reprezentacyjne [0.1%] | 144h | 144h | 6,906 | 6,906 | 6,556 |
| 3 | 2.1 | Określenie potrzeb |  | 1d | 2008-04-01 09:00 A | 2008-04-01 18:00 A | 1 | 100% |  | 2008-04-01 09:00 | 2008-04-01 18:00 | 1d |  |  |  |  | Asystentka prezesa; Administrator budynku; Prezes | 24h | 24h | 1,600 | 1,600 | 1,600 |
| 4 | 2.2 | Przygotowanie ogłoszenia |  | 0.5d? | 2008-04-02 09:00 A | 2008-04-02 13:00 A | 3 | 100% |  | 2008-04-02 09:00 | 2008-04-02 13:00 | 0.5d? |  | finish no later than 2008-04-07 18:00 |  |  | Grafik; Komputer | 8h | 8h | 252 | 252 | 252 |
| 5 | 2.3 | Emisja ogłoszenia |  | 1d | 2008-04-10 09:00 A | 2008-04-10 18:00 A | 4 | 100% |  | 2008-04-10 09:00 | 2008-04-10 18:00 | 1d |  | must start on 2008-04-10 09:00 |  |  | Moduł ogłoszeniowy cz-b [3 moduł] |  |  | 540 | 540 | 540 |
| 6 | 2.4 | **Rozpatrywanie ofert** |  | 10.62d? | 2008-04-02 14:00 A | 2008-04-17 10:00 A |  | 100% |  | 2008-04-02 14:00 | 2008-04-17 10:00 | 10.62d? |  |  |  |  | Koszty reprezentacyjne [0%] | 92h | 92h | 3,028 | 3,028 | 2,728 |
| 7 | 2.4.1 | **Ocena ofert** |  | 10.62d? | 2008-04-02 14:00 A | 2008-04-17 10:00 A |  | 100% |  | 2008-04-02 14:00 | 2008-04-17 10:00 | 10.62d? |  |  |  |  |  | 92h | 92h | 2,828 | 2,828 | 2,528 |
| 8 | 2.4.1.1 | Definiowanie kryteriów oceny |  | 0.5d | 2008-04-02 14:00 A | 2008-04-02 18:00 A | 4 | 100% |  | 2008-04-02 14:00 | 2008-04-02 18:00 | 0.5d |  |  |  |  | Asystentka prezesa; Administrator budynku; Prezes | 12h | 12h | 800 | 800 | 800 |
| 9 | 2.4.1.2 | Wpisywanie zgłoszonych ofert |  | 1d? | 2008-04-11 09:00 A | 2008-04-11 18:00 A | 5, 8 | 100% |  | 2008-04-11 09:00 | 2008-04-11 18:00 | 1d? |  |  |  |  | Komputer; Asystentka prezesa | 16h | 16h | 264 | 264 | 264 |
| 10 | 2.4.1.3 | Wizyty w lokalach |  | 3d? | 2008-04-14 09:00 A | 2008-04-16 18:00 A | 9 | 100% |  | 2008-04-14 09:00 | 2008-04-16 18:00 | 3d? |  |  |  |  | Sekretarka; Administrator budynku; Koszty delegacji [0.1%] | 48h | 48h | 1,214 | 1,214 | 914 |
| 11 | 2.4.1.4 | Przypisywanie ocen |  | 1d | 2008-04-16 18:00 A | 2008-04-17 10:00 A | 10FF | 100% |  | 2008-04-16 18:00 | 2008-04-17 10:00 | 1d |  |  |  | Wydłużone godziny pracy | Asystentka prezesa; Administrator budynku | 16h | 16h | 400 | 400 | 400 |
| 12 | 2.5 | Spisanie i zebranie ocen |  | 1d | 2008-04-17 10:00 A | 2008-04-18 10:00 A | 11 | 100% |  | 2008-04-17 10:00 | 2008-04-18 10:00 | 1d |  |  | 2008-05-05 18:00 |  | Sekretarka; Komputer | 16h | 16h | 152 | 152 | 152 |
| 13 | 2.6 | Wybór lokalu | milestone | 0d | 2008-04-18 10:00 A | 2008-04-18 10:00 A | 12 | 100% |  | 2008-04-18 10:00 | 2008-04-18 10:00 | 0d |  |  |  |  |  |  |  |  |  |  |
| 14 | 2.7 | Wysyłanie powiadomień o decyzji |  | 0.5d | 2008-04-18 10:00 A | 2008-04-18 15:00 A | 13 | 100% |  | 2008-04-18 10:00 | 2008-04-18 15:00 | 0.5d |  |  |  |  | Sekretarka; Koszty korespondencji [0.1%] | 4h | 4h | 134 | 134 | 84 |
| 15 | 3 | **Przygotowania do przeprowadzki** |  | 30.92d? | 2008-04-21 09:00 A | 2008-06-04 17:20 |  | 99% | 0.37d? | 2008-04-21 09:00 | 2008-05-28 15:20 | 25.67d? | 4.98d |  |  |  |  | 317.8h | 309.8h | 13,953.33 | 13,533.33 | 13,108 |
| 16 | 3.1 | Opiniowanie umowy |  | 2d | 2008-04-21 09:00 A | 2008-04-23 13:00 A | 14 | 100% |  | 2008-04-21 09:00 | 2008-04-23 13:00 | 2d |  |  |  |  | Prawnik | 16h | 16h | 150 | 150 | 150 |
| 17 | 3.2 | Podpisanie umowy |  | 2h | 2008-04-23 14:00 A | 2008-04-23 16:00 A | 16 | 100% |  | 2008-04-23 14:00 | 2008-04-23 16:00 | 2h |  |  |  |  | Prezes | 2h | 2h | 300 | 300 | 300 |
| 18 | 3.3 | Wypowiedzenie umowy |  | 1h | 2008-04-23 12:00 A | 2008-04-23 14:00 A | 17SF | 100% |  | 2008-04-23 12:00 | 2008-04-23 14:00 | 1h |  |  |  |  | Prezes | 1h | 1h | 150 | 150 | 150 |
| 19 | 3.4 | Zdanie lokalu |  | 0.33d? | 2008-06-04 14:40 | 2008-06-04 17:20 | 26 |  |  | 2008-05-28 11:40 | 2008-05-28 15:20 | 0.33d? | 4.98d |  |  |  | Prezes; Administrator budynku; Asystentka prezesa | 8h |  | 833.33 | 833.33 |  |
| 20 | 3.5 | Ustalenie terminu przeprowadzki |  | 0d? | 2008-04-23 16:00 A | 2008-04-23 16:01 A | 17 | 100% |  | 2008-04-23 16:00 | 2008-04-23 16:00 | 0d? |  |  |  |  | Administrator budynku; Asystentka prezesa | 8h | 8h | 300 | 300 | 300 |
| 21 | 3.6 | Aranżacja wnętrz |  | 1.26mo | 2008-04-23 16:00 A | 2008-05-30 18:00 A | 17 | 100% |  | 2008-04-23 16:00 | 2008-05-23 16:00 | 1mo |  |  |  |  | Firma architektoniczno budowlana; Asystentka prezesa [20%]; Administrator budynku [20%] | 282.8h | 282.8h | 11,020 | 10,600 | 11,020 |
| 22 | 4 | **Przeprowadzka** |  | 33.15d | 2008-04-23 16:00 A | 2008-06-11 17:10 |  | 7% | 30.74d | 2008-04-23 16:00 | 2008-06-04 15:10 | 27.9d | 0d |  |  |  |  | 260.5h | 8h | 13,502 | 13,802 | 190 |
| 23 | 4.1 | Poszukiwanie środka transportu |  | 1d | 2008-04-23 16:00 A | 2008-04-24 16:00 A | 20 | 100% |  | 2008-04-23 16:00 | 2008-04-24 16:00 | 1d |  |  |  |  | Sekretarka | 8h | 8h | 148 | 148 | 148 |
| 24 | 4.2 | Odebranie lokalu |  | 1.62d | 2008-05-31 09:00 | 2008-06-02 18:00 | 21, 23 |  |  | 2008-05-23 16:00 | 2008-05-26 16:00 | 1.62d | 0d |  |  |  | Prezes; Administrator budynku; Koszty reprezentacyjne [1.9%] | 16h |  | 2,860 | 2,860 |  |
| 25 | 4.3 | Pakowanie wyposażenia |  | 1.33d | 2008-06-03 09:00 | 2008-06-04 11:40 | 21, 24 |  |  | 2008-05-26 16:00 | 2008-05-28 09:40 | 1.33d | 0d |  |  |  | Pracownik pomocniczy [300%] | 32h |  | 498 | 498 |  |
| 26 | 4.4 | Wynoszenie wyposażenia |  | 2h | 2008-06-04 11:40 | 2008-06-04 14:40 | 25 |  |  | 2008-05-28 09:40 | 2008-05-28 11:40 | 2h | 0d |  |  |  | Pracownik pomocniczy [300%] | 6h |  | 84 | 84 |  |
| 27 | 4.5 | Załadunek |  | 1h | 2008-06-04 14:10 | 2008-06-04 15:10 | 26FS-2.5% |  |  | 2008-05-28 11:10 | 2008-05-28 12:10 | 1h | 0d |  |  |  | Firma przeprowadzkowa | 1h |  | 200 | 200 |  |
| 28 | 4.6 | Transport |  | 0.5h | 2008-06-04 15:10 | 2008-06-04 15:40 | 27 |  |  | 2008-05-28 12:10 | 2008-05-28 12:40 | 0.5h | 0d |  |  |  | Firma transportowa | 0.5h |  | 6,000 | 6,300 |  |
| 29 | 4.7 | Wyładunek |  | 1h | 2008-06-04 15:40 | 2008-06-04 16:40 | 28 |  |  | 2008-05-28 12:40 | 2008-05-28 14:40 | 1h | 0d |  |  |  | Pracownik pomocniczy [300%] | 3h |  | 42 | 42 |  |
| 30 | 4.8 | Wnoszenie wyposażenia |  | 2h | 2008-06-04 16:10 | 2008-06-05 09:10 | 29FS-5% |  |  | 2008-05-28 14:10 | 2008-05-28 16:10 | 2h | 0d |  |  |  | Firma przeprowadzkowa | 2h |  | 400 | 400 |  |
| 31 | 4.9 | Rozlokowanie sprzętu |  | 4d | 2008-06-04 16:40 | 2008-06-10 16:40 | 30FS-7.5% |  |  | 2008-05-28 14:40 | 2008-06-03 14:40 | 4d | 0.06d |  |  |  | Pracownik pomocniczy [150%]; Elektryk [50%]; Informatyk [50%] | 80h |  | 1,488 | 1,488 |  |
| 32 | 4.10 | Rozlokowanie wyposażenia |  | 4d | 2008-06-04 17:10 | 2008-06-10 17:10 | 30FS-5% |  |  | 2008-05-28 15:10 | 2008-06-03 15:10 | 4d | 0d |  |  |  | Pracownik pomocniczy [150%]; Elektryk [50%]; Informatyk [50%] | 80h |  | 736 | 736 |  |
| 33 | 4.11 | Sprzątanie |  | 1d | 2008-06-10 17:10 | 2008-06-11 17:10 | 31, 32 |  |  | 2008-06-03 15:10 | 2008-06-04 15:10 | 1d | 0d |  |  |  | Pracownik pomocniczy [300%]; Sprzątaczka | 32h |  | 446 | 446 |  |
| 34 | 5 | Koniec | milestone | 0d | 2008-06-11 17:10 | 2008-06-11 17:10 | 19, 33 |  |  | 2008-06-04 15:10 | 2008-06-04 15:10 | 0d | 0d |  |  |  |  |  |  |  |  |  |

Notes:
- 3: Problematykę tą należy dodatkowo skonsultować z Janem Malinowskim i Krystyną Kowalską. Należy wziąć pod uwagę takie elementy jak: / ·wielkość powierzchni / ·podłączenie do internetu / ·klimatyzację

| ID | WBS | Task | Duration | Start | Finish | Complete | Remaining | Baseline start | Baseline finish | Baseline duration | Total slack | Constraint |
| --- | --- | --- | --- | --- | --- | --- | --- | --- | --- | --- | --- | --- |
| 35 | 6 | **Przygotowanie raportu** | 38.25d | 2008-04-04 09:00 A | 2008-05-30 11:00 | 44% | 21.25d | 2008-04-04 09:00 | 2008-05-30 11:00 | 38.25d | 8.65d |  |
| 36 | 6.1 | Przygotowanie raportu 1 | 2h | 2008-04-04 09:00 A | 2008-04-04 11:00 A | 100% |  | 2008-04-04 09:00 | 2008-04-04 11:00 | 2h |  | start no earlier than 2008-04-04 09:00 |
| 37 | 6.2 | Przygotowanie raportu 2 | 2h | 2008-04-11 09:00 A | 2008-04-11 11:00 A | 100% |  | 2008-04-11 09:00 | 2008-04-11 11:00 | 2h |  | start no earlier than 2008-04-11 09:00 |
| 38 | 6.3 | Przygotowanie raportu 3 | 2h | 2008-04-18 09:00 A | 2008-04-18 11:00 A | 100% |  | 2008-04-18 09:00 | 2008-04-18 11:00 | 2h |  | start no earlier than 2008-04-18 09:00 |
| 39 | 6.4 | Przygotowanie raportu 4 | 2h | 2008-04-25 09:00 A | 2008-04-25 11:00 A | 100% |  | 2008-04-25 09:00 | 2008-04-25 11:00 | 2h |  | start no earlier than 2008-04-25 09:00 |
| 40 | 6.5 | Przygotowanie raportu 5 | 2h | 2008-05-02 09:00 | 2008-05-02 11:00 |  |  | 2008-05-02 09:00 | 2008-05-02 11:00 | 2h | 19.06d | start no earlier than 2008-05-02 09:00 |
| 41 | 6.6 | Przygotowanie raportu 6 | 2h | 2008-05-09 09:00 | 2008-05-09 11:00 |  |  | 2008-05-09 09:00 | 2008-05-09 11:00 | 2h | 14.06d | start no earlier than 2008-05-09 09:00 |
| 42 | 6.7 | Przygotowanie raportu 7 | 2h | 2008-05-16 09:00 | 2008-05-16 11:00 |  |  | 2008-05-16 09:00 | 2008-05-16 11:00 | 2h | 9.06d | start no earlier than 2008-05-16 09:00 |
| 43 | 6.8 | Przygotowanie raportu 8 | 2h | 2008-05-23 09:00 | 2008-05-23 11:00 |  |  | 2008-05-23 09:00 | 2008-05-23 11:00 | 2h | 5.06d | start no earlier than 2008-05-23 09:00 |
| 44 | 6.9 | Przygotowanie raportu 9 | 2h | 2008-05-30 09:00 | 2008-05-30 11:00 |  |  | 2008-05-30 09:00 | 2008-05-30 11:00 | 2h | 8.65d | start no earlier than 2008-05-30 09:00 |
